# Technology Rollout - managing projects

Schedule from MS Project, 2019-01-21 to 2019-03-22, costs in $, A marks actual dates.
Microsoft

## Calendars

- Standard: Mon-Fri 08:00-12:00, 13:00-17:00; Sat-Sun off.

## Resources

| Resource | Unit | Rate |
| --- | --- | --- |
| Information Technology Staff |  | 25 |
| Branch Manager |  |  |
| Maintenance Staff |  | 20 |
| Product Vendor |  |  |
| Network Vendor |  |  |
| Construction |  |  |
| Cable | ft. | 1.25 |
| Lunch for Crew |  |  |

## Schedule

| ID | WBS | Task | Type | Duration | Start | Finish | Predecessors | Complete | Baseline start | Baseline finish | Baseline duration | Resources | Work | Actual work | Cost | Baseline cost | Actual cost |
| --- | --- | --- | --- | --- | --- | --- | --- | --- | --- | --- | --- | --- | --- | --- | --- | --- | --- |
| 1 | 1 | **Phase One** |  | 9.25d | 2019-01-21 A | 2019-02-01 A |  | 100% | 2013-03-04 | 2013-03-15 | 9.25d |  | 114h | 114h | 2,850 | 2,850 | 2,850 |
| 2 | 1.1 | Survey staff for technology needs |  | 1w | 2019-01-21 A | 2019-01-25 A |  | 100% | 2013-03-04 | 2013-03-08 | 1w | Information Technology Staff [200%] | 80h | 80h | 2,000 | 2,000 | 2,000 |
| 3 | 1.2 | Compile survey results |  | 1d | 2019-01-28 A | 2019-01-28 A | 2 | 100% | 2013-03-11 | 2013-03-11 | 1d | Information Technology Staff | 8h | 8h | 200 | 200 | 200 |
| 4 | 1.3 | Send RFQ to vendors |  | 2h | 2019-01-29 A | 2019-01-29 A | 3 | 100% | 2013-03-12 | 2013-03-12 | 2h | Information Technology Staff | 2h | 2h | 50 | 50 | 50 |
| 5 | 1.4 | Compare quotes |  | 2d | 2019-01-29 A | 2019-01-31 A | 4 | 100% | 2013-03-12 | 2013-03-14 | 2d | Information Technology Staff | 16h | 16h | 400 | 400 | 400 |
| 6 | 1.5 | Order material |  | 1d | 2019-01-31 A | 2019-02-01 A | 5 | 100% | 2013-03-14 | 2013-03-15 | 1d | Information Technology Staff | 8h | 8h | 200 | 200 | 200 |
| 7 | 1.6 | Phase One Complete | milestone | 0d | 2019-02-01 A | 2019-02-01 A | 6 | 100% | 2013-03-15 | 2013-03-15 | 0d |  |  |  |  |  |  |
| 8 | 2 | **Phase Two** |  | 6d | 2019-02-01 A | 2019-02-11 A |  | 100% | 2013-03-15 | 2013-03-25 | 6d |  | 72h | 72h | 400 | 400 | 400 |
| 9 | 2.1 | Pull/install cable |  | 1w | 2019-02-01 A | 2019-02-08 A | 7 | 100% | 2013-03-15 | 2013-03-22 | 1w | Network Vendor | 40h | 40h |  |  |  |
| 10 | 2.2 | Install panel |  | 1d | 2019-02-01 A | 2019-02-04 A | 9SS | 100% | 2013-03-15 | 2013-03-18 | 1d | Network Vendor; Information Technology Staff | 16h | 16h | 200 | 200 | 200 |
| 11 | 2.3 | Connect and test |  | 1d | 2019-02-08 A | 2019-02-11 A | 9 | 100% | 2013-03-22 | 2013-03-25 | 1d | Network Vendor; Information Technology Staff | 16h | 16h | 200 | 200 | 200 |
| 12 | 2.4 | Phase Two Complete | milestone | 0d | 2019-02-11 A | 2019-02-11 A | 11 | 100% | 2013-03-25 | 2013-03-25 | 0d |  |  |  |  |  |  |
| 13 | 3 | **Phase Three** |  | 6d | 2019-02-11 A | 2019-02-19 A |  | 100% | 2013-04-01 | 2013-04-08 | 6d |  | 112h | 112h | 1,800 | 1,800 | 1,800 |
| 14 | 3.1 | Equipment placed |  | 1w | 2019-02-11 A | 2019-02-18 A | 12 | 100% | 2013-04-01 | 2013-04-05 | 1w | Product Vendor; Information Technology Staff | 80h | 80h | 1,000 | 1,000 | 1,000 |
| 15 | 3.2 | Install software/updates |  | 1d | 2019-02-18 A | 2019-02-19 A | 14 | 100% | 2013-04-08 | 2013-04-08 | 1d | Information Technology Staff [400%] | 32h | 32h | 800 | 800 | 800 |
| 16 | 3.3 | Phase Three Complete | milestone | 0d | 2019-02-19 A | 2019-02-19 A | 15 | 100% | 2013-04-08 | 2013-04-08 | 0d |  |  |  |  |  |  |
| 17 | 4 | **Phase Four** |  | 23d | 2019-02-19 A | 2019-03-22 A |  | 100% | 2013-04-09 | 2013-05-09 | 22.5d |  | 424h | 424h | 9,000 | 9,000 | 9,000 |
| 18 | 4.1 | Survey staff for training needs |  | 1w | 2019-02-19 A | 2019-02-26 A | 16 | 100% | 2013-04-09 | 2013-04-15 | 1w | Branch Manager | 40h | 40h |  |  |  |
| 19 | 4.2 | Compile survey results |  | 2d | 2019-02-26 A | 2019-02-28 A | 18 | 100% | 2013-04-16 | 2013-04-17 | 2d | Branch Manager | 16h | 16h |  |  |  |
| 20 | 4.3 | Schedule sessions |  | 8h | 2019-02-28 A | 2019-03-01 A | 19 | 100% | 2013-04-18 | 2013-04-18 | 8h | Branch Manager | 8h | 8h |  |  |  |
| 21 | 4.4 | Training |  | 2w | 2019-03-01 A | 2019-03-15 A | 20 | 100% | 2013-04-18 | 2013-05-02 | 2w | Information Technology Staff [400%] | 320h | 320h | 8,000 | 8,000 | 8,000 |
| 22 | 4.5 | Post training survey |  | 1w | 2019-03-15 A | 2019-03-22 A | 21 | 100% | 2013-05-02 | 2013-05-09 | 1w | Information Technology Staff | 40h | 40h | 1,000 | 1,000 | 1,000 |
| 23 | 4.6 | Phase Four Complete | milestone | 0d | 2019-03-22 A | 2019-03-22 A | 22 | 100% | 2013-05-09 | 2013-05-09 | 0d |  |  |  |  |  |  |

Notes:
- 4: TB_3-8-2013: Send by email and fax.
