# Technology Rollout

Schedule from MS Project, 2019-01-21 to 2019-03-15, costs in $.
Microsoft

## Calendars

- Standard: Mon-Fri 08:00-12:00, 13:00-17:00; Sat-Sun off.

## Resources

| Resource | Unit | Rate |
| --- | --- | --- |
| Information Technology |  | 25 |
| Branch Manager |  |  |
| Maintenance Staff |  | 20 |
| Product Vendor |  |  |
| Network Vendor |  |  |
| Construction |  |  |
| Cable | ft. | 1.25 |
| Lunch For Crew |  |  |

## Schedule

| ID | WBS | Task | Type | Duration | Start | Finish | Predecessors | Baseline start | Baseline finish | Baseline duration | Total slack | Free slack | Constraint | Resources | Work | Cost | Baseline cost |
| --- | --- | --- | --- | --- | --- | --- | --- | --- | --- | --- | --- | --- | --- | --- | --- | --- | --- |
| 1 | 1 | **Phase One** |  | 9.25d | 2019-01-21 | 2019-02-01 |  | 2019-01-21 | 2019-02-01 | 9.25d | -0.25d | 0d |  |  | 114h | 2,850 | 2,850 |
| 2 | 1.1 | Survey staff for technology needs |  | 1w | 2019-01-21 | 2019-01-25 |  | 2019-01-21 | 2019-01-25 | 1w | -0.25d | 0d |  | Information Technology [200%] | 80h | 2,000 | 2,000 |
| 3 | 1.2 | Compile survey results |  | 1d | 2019-01-28 | 2019-01-28 | 2 | 2019-01-28 | 2019-01-28 | 1d | -0.25d | 0d |  | Information Technology | 8h | 200 | 200 |
| 4 | 1.3 | Send RFQ to vendors |  | 2h | 2019-01-29 | 2019-01-29 | 3 | 2019-01-29 | 2019-01-29 | 2h | -0.25d | 0d |  | Information Technology | 2h | 50 | 50 |
| 5 | 1.4 | Compare quotes |  | 2d | 2019-01-29 | 2019-01-31 | 4 | 2019-01-29 | 2019-01-31 | 2d | -0.25d | 0d |  | Information Technology | 16h | 400 | 400 |
| 6 | 1.5 | Order material |  | 1d | 2019-01-31 | 2019-02-01 | 5 | 2019-01-31 | 2019-02-01 | 1d | -0.25d | 0d |  | Information Technology | 8h | 200 | 200 |
| 7 | 1.6 | Phase One Complete | milestone | 0d | 2019-02-01 | 2019-02-01 | 6 | 2019-02-01 | 2019-02-01 | 0d | -0.25d | 0d |  |  |  |  |  |
| 8 | 2 | **Phase Two** |  | 5d | 2019-02-01 | 2019-02-08 |  | 2019-02-01 | 2019-02-08 | 5d | -0.25d | 0d |  |  | 72h | 400 | 400 |
| 9 | 2.1 | Pull/install cable |  | 1w | 2019-02-01 | 2019-02-08 | 7 | 2019-02-01 | 2019-02-08 | 1w | -0.25d | 0d |  | Network Vendor | 40h |  |  |
| 10 | 2.2 | Install panel |  | 1d | 2019-02-01 | 2019-02-04 | 9SS | 2019-02-01 | 2019-02-04 | 1d | -0.25d | 0d |  | Information Technology; Network Vendor | 16h | 200 | 200 |
| 11 | 2.3 | Connect and test |  | 1d | 2019-02-04 | 2019-02-05 | 10 | 2019-02-04 | 2019-02-05 | 1d | -0.25d | 0d |  | Information Technology; Network Vendor | 16h | 200 | 200 |
| 12 | 2.4 | Phase Two Complete | milestone | 0d | 2019-02-05 | 2019-02-05 | 11 | 2019-02-05 | 2019-02-05 | 0d | -0.25d | 0d |  |  |  |  |  |
| 13 | 3 | **Phase Three** |  | 6d | 2019-02-05 | 2019-02-12 |  | 2019-02-05 | 2019-02-13 | 6d | 0d |  |  |  | 112h | 1,800 | 1,800 |
| 14 | 3.1 | Equipment placed |  | 1w | 2019-02-05 | 2019-02-11 | 12 | 2019-02-05 | 2019-02-12 | 1w | -0.25d | 0d | finish no later than 2019-02-11 | Product Vendor; Information Technology | 80h | 1,000 | 1,000 |
| 15 | 3.2 | Install software/updates |  | 1d | 2019-02-12 | 2019-02-12 | 14 | 2019-02-12 | 2019-02-13 | 1d | 0d |  |  | Information Technology [400%] | 32h | 800 | 800 |
| 16 | 3.3 | Phase Three Complete | milestone | 0d | 2019-02-12 | 2019-02-12 | 15 | 2019-02-13 | 2019-02-13 | 0d | 0d |  |  |  |  |  |  |
| 17 | 4 | **Phase Four** |  | 22.5d | 2019-02-13 | 2019-03-15 |  | 2019-02-13 | 2019-03-15 | 22.5d | 0d |  |  |  | 420h | 9,000 | 9,000 |
| 18 | 4.1 | Survey staff for training needs |  | 1w | 2019-02-13 | 2019-02-19 | 16 | 2019-02-13 | 2019-02-20 | 1w | 0d |  |  | Branch Manager | 40h |  |  |
| 19 | 4.2 | Compile survey results |  | 2d | 2019-02-20 | 2019-02-21 | 18 | 2019-02-20 | 2019-02-22 | 2d | 0d |  |  | Branch Manager | 16h |  |  |
| 20 | 4.3 | Schedule Sessions |  | 4h | 2019-02-22 | 2019-02-22 | 19 | 2019-02-22 | 2019-02-22 | 4h | 0d |  |  | Branch Manager | 4h |  |  |
| 21 | 4.4 | Training |  | 2w | 2019-02-22 | 2019-03-08 | 20 | 2019-02-22 | 2019-03-08 | 2w | 0d |  |  | Information Technology [400%] | 320h | 8,000 | 8,000 |
| 22 | 4.5 | Post training survey |  | 1w | 2019-03-08 | 2019-03-15 | 21 | 2019-03-08 | 2019-03-15 | 1w | 0d |  |  | Information Technology | 40h | 1,000 | 1,000 |
| 23 | 4.6 | Phase Four Complete | milestone | 0d | 2019-03-15 | 2019-03-15 | 22 | 2019-03-15 | 2019-03-15 | 0d | 0d |  |  |  |  |  |  |

Notes:
- 4: TB_3-8-2013: Send by email and fax.
