# Planning a Book Launch - Adding Notes

Schedule from MS Project, 2019-01-21 to 2019-09-13, costs in $, A marks actual dates.
Webucator

## Calendars

- Book Launch calendar: Mon-Fri 09:00-17:00; Sat-Sun off.

## Resources

| Resource | Rate | Cost per use |
| --- | --- | --- |
| Writers | 45 |  |
| Subject Matter Experts | 40 |  |
| Editors |  |  |
| Interns |  |  |
| Programmer | 35 |  |
| Print Vendor |  |  |
| Marketing Firm |  |  |
| Paper |  | 125 |
| Book Signing Party |  |  |

## Schedule

| ID | WBS | Task | Type | Duration | Start | Finish | Predecessors | Complete | Baseline start | Baseline finish | Baseline duration | Resources | Work | Actual work | Cost | Baseline cost | Actual cost |
| --- | --- | --- | --- | --- | --- | --- | --- | --- | --- | --- | --- | --- | --- | --- | --- | --- | --- |
| 1 | 1 | **Phase One** |  | 7d | 2019-01-21 A | 2019-01-29 A |  | 100% | 2019-01-21 | 2019-01-29 | 7d |  | 72h | 72h | 2,440 | 2,440 | 2,440 |
| 2 | 1.1 | Content Assessment | milestone | 0d | 2019-01-21 A | 2019-01-21 A |  | 100% | 2019-01-21 | 2019-01-21 | 0d | Writers; Subject Matter Experts |  |  |  |  |  |
| 3 | 1.2 | Outline Submission |  | 1w | 2019-01-21 A | 2019-01-25 A | 2 | 100% | 2019-01-21 | 2019-01-25 | 1w | Writers | 40h | 40h | 1,800 | 1,800 | 1,800 |
| 4 | 1.3 | Outline Approval |  | 2d | 2019-01-28 A | 2019-01-29 A | 3 | 100% | 2019-01-28 | 2019-01-29 | 2d | Editors; Subject Matter Experts | 32h | 32h | 640 | 640 | 640 |
| 5 | 1.4 | Phase One Complete | milestone | 0d | 2019-01-29 A | 2019-01-29 A | 4 | 100% | 2019-01-29 | 2019-01-29 | 0d |  |  |  |  |  |  |
| 6 | 2 | **Phase Two** |  | 35d | 2019-01-30 A | 2019-03-19 A |  | 100% | 2019-01-30 | 2019-03-19 | 35d |  | 920h | 920h | 36,600 | 36,600 | 36,600 |
| 7 | 2.1 | Content Research |  | 2w | 2019-01-30 A | 2019-02-12 A | 5 | 100% | 2019-01-30 | 2019-02-12 | 2w | Writers [200%]; Subject Matter Experts | 240h | 240h | 10,400 | 10,400 | 10,400 |
| 8 | 2.2 | Content Development |  | 3w | 2019-02-13 A | 2019-03-05 A | 7 | 100% | 2019-02-13 | 2019-03-05 | 3w | Writers [300%] | 360h | 360h | 16,200 | 16,200 | 16,200 |
| 9 | 2.3 | Content Edits |  | 2w | 2019-02-27 A | 2019-03-12 A | 8FS-1w | 100% | 2019-02-27 | 2019-03-12 | 2w | Editors; Writers | 160h | 160h | 3,600 | 3,600 | 3,600 |
| 10 | 2.4 | Content Review |  | 2w | 2019-03-06 A | 2019-03-19 A | 9FS-1w | 100% | 2019-03-06 | 2019-03-19 | 2w | Subject Matter Experts [200%] | 160h | 160h | 6,400 | 6,400 | 6,400 |
| 11 | 2.5 | Phase Two Complete | milestone | 0d | 2019-03-19 A | 2019-03-19 A | 10 | 100% | 2019-03-19 | 2019-03-19 | 0d |  |  |  |  |  |  |
| 12 | 3 | **Phase Three** |  | 113d | 2019-03-20 A | 2019-08-23 A |  | 100% | 2019-03-20 | 2019-04-23 | 25d |  | 1000h | 1000h | 29,600 | 5,800 | 29,600 |
| 13 | 3.1 | Media Research Options |  | 1w | 2019-03-20 A | 2019-03-26 A | 10 | 100% | 2019-03-20 | 2019-03-26 | 1w | Interns [200%]; Marketing Firm | 120h | 120h |  |  |  |
| 14 | 3.2 | Content Conversion for Media |  | 20w | 2019-04-01 A | 2019-08-16 A | 13 | 100% | 2019-03-27 | 2019-04-16 | 3w | Programmer | 800h | 800h | 28,000 | 4,200 | 28,000 |
| 15 | 3.3 | Final Content Review |  | 1w | 2019-08-19 A | 2019-08-23 A | 14 | 100% | 2019-04-17 | 2019-04-23 | 1w | Editors; Subject Matter Experts | 80h | 80h | 1,600 | 1,600 | 1,600 |
| 16 | 3.4 | Phase Three Complete | milestone | 0d | 2019-08-23 A | 2019-08-23 A | 15 | 100% | 2019-04-23 | 2019-04-23 | 0d |  |  |  |  |  |  |
| 17 | 4 | **Phase Four** |  | 15d | 2019-08-26 A | 2019-09-13 A |  | 100% | 2019-04-24 | 2019-05-14 | 15d |  | 280h | 280h | 125 | 125 | 125 |
| 18 | 4.1 | Marketing Plan |  | 1w | 2019-08-26 A | 2019-08-30 A | 16 | 100% | 2019-04-24 | 2019-04-30 | 1w | Interns [200%]; Marketing Firm | 120h | 120h |  |  |  |
| 19 | 4.2 | Production |  | 2w | 2019-08-26 A | 2019-09-06 A | 15 | 100% | 2019-04-24 | 2019-05-07 | 2w | Print Vendor; Paper [10000%] | 80h | 80h | 125 | 125 | 125 |
| 20 | 4.3 | Delivery of Book to Market |  | 1w | 2019-09-09 A | 2019-09-13 A | 19 | 100% | 2019-05-08 | 2019-05-14 | 1w | Marketing Firm; Interns | 80h | 80h |  |  |  |
| 21 | 4.4 | Phase Four Complete | milestone | 0d | 2019-09-13 A | 2019-09-13 A | 20 | 100% | 2019-05-14 | 2019-05-14 | 0d |  |  |  |  |  |  |

Notes:
- 4: TB_3-10-2013: Make sure each editor signs off on the outline.
