# Technology Rollout

Schedule from MS Project, 2019-01-21 to 2019-03-15.
Microsoft

## Calendars

- Standard: Mon-Fri 08:00-12:00, 13:00-17:00; Sat-Sun off.

## Schedule

| ID | WBS | Task | Type | Duration | Start | Finish | Predecessors | Total slack |
| --- | --- | --- | --- | --- | --- | --- | --- | --- |
| 1 | 1 | **Phase One** |  | 9.25d | 2019-01-21 | 2019-02-01 |  | 0d |
| 2 | 1.1 | Survey staff for technology needs |  | 1w | 2019-01-21 | 2019-01-25 |  | 0d |
| 3 | 1.2 | Compile survey results |  | 1d | 2019-01-28 | 2019-01-28 | 2 | 0d |
| 4 | 1.3 | Send RFQ to vendors |  | 2h | 2019-01-29 | 2019-01-29 | 3 | 0d |
| 5 | 1.4 | Compare quotes |  | 2d | 2019-01-29 | 2019-01-31 | 4 | 0d |
| 6 | 1.5 | Order material |  | 1d | 2019-01-31 | 2019-02-01 | 5 | 0d |
| 7 | 1.6 | Phase One Complete | milestone | 0d | 2019-02-01 | 2019-02-01 | 6 | 0d |
| 8 | 2 | **Phase Two** |  | 5d | 2019-02-01 | 2019-02-08 |  | 0d |
| 9 | 2.1 | Pull/install cable |  | 1w | 2019-02-01 | 2019-02-08 | 7 | 0d |
| 10 | 2.2 | Install panel |  | 1d | 2019-02-01 | 2019-02-04 | 9SS | 0d |
| 11 | 2.3 | Connect and test |  | 1d | 2019-02-04 | 2019-02-05 | 10 | 0d |
| 12 | 2.4 | Phase Two Complete | milestone | 0d | 2019-02-05 | 2019-02-05 | 11 | 0d |
| 13 | 3 | **Phase Three** |  | 6d | 2019-02-05 | 2019-02-13 |  | 0d |
| 14 | 3.1 | Equipment placed |  | 1w | 2019-02-05 | 2019-02-12 | 12 | 0d |
| 15 | 3.2 | Install software/updates |  | 1d | 2019-02-12 | 2019-02-13 | 14 | 0d |
| 16 | 3.3 | Phase Three Complete | milestone | 0d | 2019-02-13 | 2019-02-13 | 15 | 0d |
| 17 | 4 | **Phase Four** |  | 22.5d | 2019-02-13 | 2019-03-15 |  | 0d |
| 18 | 4.1 | Survey staff for training needs |  | 1w | 2019-02-13 | 2019-02-20 | 16 | 0d |
| 19 | 4.2 | Compile survey results |  | 2d | 2019-02-20 | 2019-02-22 | 18 | 0d |
| 20 | 4.3 | Schedule Sessions |  | 4h | 2019-02-22 | 2019-02-22 | 19 | 0d |
| 21 | 4.4 | Training |  | 2w | 2019-02-22 | 2019-03-08 | 20 | 0d |
| 22 | 4.5 | Post training survey |  | 1w | 2019-03-08 | 2019-03-15 | 21 | 0d |
| 23 | 4.6 | Phase Four Complete | milestone | 0d | 2019-03-15 | 2019-03-15 | 22 | 0d |

Notes:
- 4: TB_3-8-2013: Send by email and fax.
