# Planning a Book Launch - Adding Notes

Schedule from MS Project, 2019-01-21 to 2019-05-14, costs in $.
Webucator

## Calendars

- Book Launch calendar: Mon-Fri 09:00-17:00; Sat-Sun off.

## Resources

| Resource | Rate | Cost per use |
| --- | --- | --- |
| Writers | 45 |  |
| Subject Matter Experts | 40 |  |
| Editors |  |  |
| Interns |  |  |
| Programmer | 35 |  |
| Print Vendor |  |  |
| Marketing Firm |  |  |
| Paper |  | 125 |
| Book Signing Party |  |  |

## Schedule

| ID | WBS | Task | Type | Duration | Start | Finish | Predecessors | Total slack | Free slack | Resources | Work | Cost |
| --- | --- | --- | --- | --- | --- | --- | --- | --- | --- | --- | --- | --- |
| 1 | 1 | **Phase One** |  | 7d | 2019-01-21 | 2019-01-29 |  | 0d |  |  | 72h | 2,440 |
| 2 | 1.1 | Content Assessment | milestone | 0d | 2019-01-21 | 2019-01-21 |  | 0d |  | Writers; Subject Matter Experts |  |  |
| 3 | 1.2 | Outline Submission |  | 1w | 2019-01-21 | 2019-01-25 | 2 | 0d |  | Writers | 40h | 1,800 |
| 4 | 1.3 | Outline Approval |  | 2d | 2019-01-28 | 2019-01-29 | 3 | 0d |  | Editors; Subject Matter Experts | 32h | 640 |
| 5 | 1.4 | Phase One Complete | milestone | 0d | 2019-01-29 | 2019-01-29 | 4 | 0d |  |  |  |  |
| 6 | 2 | **Phase Two** |  | 35d | 2019-01-30 | 2019-03-19 |  | 0d |  |  | 1000h | 40,200 |
| 7 | 2.1 | Content Research |  | 2w | 2019-01-30 | 2019-02-12 | 5 | 0d |  | Writers [200%]; Subject Matter Experts | 240h | 10,400 |
| 8 | 2.2 | Content Development |  | 3w | 2019-02-13 | 2019-03-05 | 7 | 0d |  | Writers [300%] | 360h | 16,200 |
| 9 | 2.3 | Content Edits |  | 2w | 2019-02-27 | 2019-03-12 | 8FS-1w | 0d |  | Editors; Writers [200%] | 240h | 7,200 |
| 10 | 2.4 | Content Review |  | 2w | 2019-03-06 | 2019-03-19 | 9FS-1w | 0d |  | Subject Matter Experts [200%] | 160h | 6,400 |
| 11 | 2.5 | Phase Two Complete | milestone | 0d | 2019-03-19 | 2019-03-19 | 10 | 40d |  |  |  |  |
| 12 | 3 | **Phase Three** |  | 25d | 2019-03-20 | 2019-04-23 |  | 0d |  |  | 320h | 5,800 |
| 13 | 3.1 | Media Research Options |  | 1w | 2019-03-20 | 2019-03-26 | 10 | 0d |  | Interns [200%]; Marketing Firm | 120h |  |
| 14 | 3.2 | Content Conversion for Media |  | 3w | 2019-03-27 | 2019-04-16 | 13 | 0d |  | Programmer | 120h | 4,200 |
| 15 | 3.3 | Final Content Review |  | 1w | 2019-04-17 | 2019-04-23 | 14 | 0d |  | Editors; Subject Matter Experts | 80h | 1,600 |
| 16 | 3.4 | Phase Three Complete | milestone | 0d | 2019-04-23 | 2019-04-23 | 15 | 10d | 0d |  |  |  |
| 17 | 4 | **Phase Four** |  | 15d | 2019-04-24 | 2019-05-14 |  | 0d |  |  | 280h | 125 |
| 18 | 4.1 | Marketing Plan |  | 1w | 2019-04-24 | 2019-04-30 | 16 | 10d |  | Interns [200%]; Marketing Firm | 120h |  |
| 19 | 4.2 | Production |  | 2w | 2019-04-24 | 2019-05-07 | 15 | 0d |  | Print Vendor; Paper [10000%] | 80h | 125 |
| 20 | 4.3 | Delivery of Book to Market |  | 1w | 2019-05-08 | 2019-05-14 | 19 | 0d |  | Marketing Firm; Interns | 80h |  |
| 21 | 4.4 | Phase Four Complete | milestone | 0d | 2019-05-14 | 2019-05-14 | 20 | 0d |  |  |  |  |

Notes:
- 4: TB_3-10-2013: Make sure each editor signs off on the outline.
