# Planning a Book Launch - Linking Tasks

Schedule from MS Project, 2019-01-21 to 2019-05-17.
Webucator

## Calendars

- Book Launch calendar: Mon-Fri 09:00-17:00; Sat-Sun off.

## Schedule

| ID | WBS | Task | Type | Duration | Start | Finish | Predecessors | Total slack | Constraint |
| --- | --- | --- | --- | --- | --- | --- | --- | --- | --- |
| 1 | 1 | **Phase One** |  | 10d | 2019-01-21 | 2019-02-01 |  | 0d |  |
| 2 | 1.1 | Content Assessment |  | 3d | 2019-01-21 | 2019-01-23 |  | 0d |  |
| 3 | 1.2 | Outline Submission |  | 1w | 2019-01-24 | 2019-01-30 | 2 | 0d |  |
| 4 | 1.3 | Outline Approval |  | 2d | 2019-01-31 | 2019-02-01 | 3 | 0d |  |
| 5 | 1.4 | Phase One Complete | milestone | 0d | 2019-02-01 | 2019-02-01 | 4 | 0d |  |
| 6 | 2 | **Phase Two** |  | 35d | 2019-02-04 | 2019-03-22 |  | 0d |  |
| 7 | 2.1 | Content Research |  | 2w | 2019-02-04 | 2019-02-15 | 5 | 0d |  |
| 8 | 2.2 | Content Development |  | 3w | 2019-02-18 | 2019-03-08 | 7 | 0d |  |
| 9 | 2.3 | Content Edits |  | 2w | 2019-03-04 | 2019-03-15 | 8FS-1w | 0d |  |
| 10 | 2.4 | Content Review |  | 2w | 2019-03-11 | 2019-03-22 | 9FS-1w | 0d |  |
| 11 | 2.5 | Phase Two Complete | milestone | 0d | 2019-03-22 | 2019-03-22 | 10 | 40d |  |
| 12 | 3 | **Phase Three** |  | 25d | 2019-03-25 | 2019-04-26 |  | 0d |  |
| 13 | 3.1 | Media Research Options |  | 1w | 2019-03-25 | 2019-03-29 | 10 | 0d |  |
| 14 | 3.2 | Content Conversion for Media |  | 3w | 2019-04-01 | 2019-04-19 | 13 | 0d |  |
| 15 | 3.3 | Final Content Review |  | 1w | 2019-04-22 | 2019-04-26 | 14 | 0d |  |
| 16 | 3.4 | Phase Three Complete | milestone | 0d | 2019-04-26 | 2019-04-26 | 15 | 15d |  |
| 17 | 4 | **Phase Four** |  | 15d | 2019-04-29 | 2019-05-17 |  | 0d |  |
| 18 | 4.1 | Marketing Plan |  | 1w | 2019-05-06 | 2019-05-10 |  | 5d | start no earlier than 2019-05-06 |
| 19 | 4.2 | Production | manual | 2w | 2019-04-29 | 2019-05-10 | 15 |  |  |
| 20 | 4.3 | Delivery of Book to Market |  | 1w | 2019-05-13 | 2019-05-17 | 19 | 0d |  |
| 21 | 4.4 | Phase Four Complete | milestone | 0d | 2019-05-17 | 2019-05-17 | 20 | 0d |  |
